# EvanstonDBProj

Schedule from MS Project, 2004-05-10 to 2005-05-17, costs in $, A marks actual dates.

## Calendars

- Standard: Mon-Fri 09:00-12:00, 13:00-18:00; Sat-Sun off. Exceptions (off unless hours are given): 2004-05-31, 2004-07-02, 2004-07-05, 2004-09-06.

## Resources

| Resource | Rate | Cost per use |
| --- | --- | --- |
| Analyst |  |  |
| Management |  |  |
| Project manager | 75 |  |
| Developer |  |  |
| Testers |  |  |
| Trainers |  |  |
| Technical communicators |  |  |
| Deployment team |  |  |
| CS Client Sponsor | 100 | 100 |
| A1 Analyst 1 | 70 |  |
| A2 Anslyst 2 | 70 |  |
| P1Programmer 1 | 65 |  |
| P2 Programmer 2 | 65 |  |
| T1 Tester 1 | 55 |  |
| T2 Tester 2 | 55 |  |
| TDS Training/Documentation | 60 |  |
| DBA Database Administrator | 75 |  |
| SD System Designer | 75 |  |

## Schedule

| ID | WBS | Task | Type | Duration | Start | Finish | Predecessors | Complete | Remaining | Total slack | Free slack | Resources | Work | Actual work | Cost | Actual cost |
| --- | --- | --- | --- | --- | --- | --- | --- | --- | --- | --- | --- | --- | --- | --- | --- | --- |
| 1 | 1 | **Design Evanston Database** |  | 5d | 2004-05-10 A | 2004-05-14 |  | 80% | 1d | 10.98d | 0d |  | 40h | 32h | 3,000 | 2,400 |
| 2 | 1.1 | Document entities and relationships |  | 2d | 2004-05-10 A | 2004-05-11 A |  | 100% |  |  |  | SD System Designer | 16h | 16h | 1,200 | 1,200 |
| 3 | 1.2 | Determine source of each data element |  | 2d | 2004-05-13 A | 2004-05-14 A |  | 100% |  |  |  | SD System Designer | 16h | 16h | 1,200 | 1,200 |
| 4 | 1.3 | Design Member Survyer |  | 1d | 2004-05-12 | 2004-05-12 | 2 |  |  | 24d |  | SD System Designer | 8h |  | 600 |  |
| 5 | 2 | **Produce Functional Designs** |  | 24.5d | 2004-05-17 A | 2004-06-21 | 1 | 45% | 13.52d | 0d |  |  | 216h | 89.6h | 17,000 | 6,720 |
| 6 | 2.1 | **Design Survey Production System** |  | 4.5d | 2004-06-15 A | 2004-06-21 |  | 89% | 0.5d | 0d |  |  | 40h | 32h | 3,200 | 2,400 |
| 7 | 2.1.1 | Develop functional specifications |  | 4d | 2004-06-15 A | 2004-06-18 A |  | 100% |  |  |  | SD System Designer | 32h | 32h | 2,400 | 2,400 |
| 8 | 2.1.2 | Obtain approval to proceed |  | 4h | 2004-06-21 | 2004-06-21 | 7 |  |  | 0d |  | Project manager; CS Client Sponsor | 8h |  | 800 |  |
| 9 | 2.2 | **Design Survey Processing System** |  | 5.5d | 2004-06-01 | 2004-06-08 |  |  |  | 9d |  |  | 48h |  | 3,800 |  |
| 10 | 2.2.1 | Develop functional specifications |  | 5d | 2004-06-01 | 2004-06-07 |  |  |  | 16d | 0d | SD System Designer | 40h |  | 3,000 |  |
| 11 | 2.2.2 | Obtain approval to proceed |  | 4h | 2004-06-08 | 2004-06-08 | 10 |  |  | 16d |  | Project manager; CS Client Sponsor | 8h |  | 800 |  |
| 12 | 2.3 | **Design Data Capture System** |  | 9.5d | 2004-05-17 A | 2004-05-28 |  | 76% | 2.3d | 15d |  |  | 80h | 57.6h | 6,200 | 4,320 |
| 13 | 2.3.1 | Develop functional specifications |  | 9d | 2004-05-17 A | 2004-05-27 |  | 80% | 1.8d | 15d | 0d | SD System Designer | 72h | 57.6h | 5,400 | 4,320 |
| 14 | 2.3.2 | Obtain approval to proceed |  | 4h | 2004-05-28 | 2004-05-28 | 13 |  |  | 22d |  | Project manager; CS Client Sponsor | 8h |  | 800 |  |
| 16 | 2.4 | **Design Data Publication System** |  | 5.5d | 2004-06-08 | 2004-06-15 |  |  |  | 4d |  |  | 48h |  | 3,800 |  |
| 17 | 2.4.1 | Develop functional specifications |  | 5d | 2004-06-08 | 2004-06-14 |  |  |  | 11d | 0d | SD System Designer | 40h |  | 3,000 |  |
| 18 | 2.4.2 | Obtain approval to proceed |  | 4h | 2004-06-15 | 2004-06-15 | 17 |  |  | 11d |  | Project manager; CS Client Sponsor | 8h |  | 800 |  |
| 20 | 3 | Functional Design Complete | milestone | 0d | 2004-06-21 | 2004-06-21 | 6, 9, 12, 16 |  |  | 0d |  |  |  |  |  |  |
| 22 | 4 | **Estimate Development Costs** |  | 5.5d | 2004-06-21 A | 2004-06-28 | 20 | 42% | 3.21d | 7d | 0d |  | 96h | 40h | 6,960 | 2,900 |
| 23 | 4.1 | Estimate Effort |  | 5d | 2004-06-21 A | 2004-06-28 |  | 50% | 2.5d | 7.5d |  | SD System Designer; A1 Analyst 1 | 80h | 40h | 5,800 | 2,900 |
| 24 | 4.2 | Document additional hardware and software costs |  | 1d | 2004-06-21 | 2004-06-28 |  |  |  | 7d |  | SD System Designer; A1 Analyst 1 | 16h |  | 1,160 |  |
| 25 | 5 | Approve Development Project | milestone | 0d | 2004-06-28 | 2004-06-28 | 22 |  |  | 7d | 0d | CS Client Sponsor; Project manager |  |  | 100 |  |
| 26 | 6 | **Develop and Deploy systems** |  | 131d | 2004-06-29 | 2004-12-31 | 25 |  |  | 0d |  |  | 1056h |  | 69,120 |  |
| 27 | 6.1 | **Develop Systems (Revise in June)** |  | 131d | 2004-06-29 | 2004-12-31 |  |  |  | 0d |  |  | 1056h |  | 69,120 |  |
| 28 | 6.1.1 | **Develop Survey Production System** |  | 124d | 2004-07-12 | 2004-12-31 |  |  |  | 0d |  |  | 184h |  | 12,080 |  |
| 29 | 6.1.1.1 | Review functional specifications |  | 1d | 2004-07-12 | 2004-07-12 |  |  |  | 0d |  | A1 Analyst 1 | 8h |  | 560 |  |
| 30 | 6.1.1.2 | Design screens and modules |  | 2d | 2004-07-13 | 2004-07-14 | 29 |  |  | 0d |  | A1 Analyst 1 | 16h |  | 1,120 |  |
| 31 | 6.1.1.3 | Develop code |  | 10d | 2004-09-27 | 2004-10-08 | 30 |  |  | 0d |  | P1Programmer 1 | 80h |  | 5,200 |  |
| 32 | 6.1.1.4 | Developer testing (primary debugging) |  | 10d | 2004-12-20 | 2004-12-31 | 31FS-7.5% |  |  | 0d |  | P1Programmer 1 | 80h |  | 5,200 |  |

| ID | WBS | Task | Type | Duration | Start | Finish | Predecessors | Total slack | Free slack | Resources | Work | Cost |
| --- | --- | --- | --- | --- | --- | --- | --- | --- | --- | --- | --- | --- |
| 33 | 6.1.2 | **Develop Survey Processing System** |  | 108d | 2004-07-06 | 2004-12-03 |  | 20d |  |  | 264h | 17,280 |
| 34 | 6.1.2.1 | Review functional specifications |  | 1d | 2004-07-06 | 2004-07-06 |  | 23.25d | 0d | A2 Anslyst 2 | 8h | 560 |
| 35 | 6.1.2.2 | Design screens and modules |  | 2d | 2004-07-08 | 2004-07-09 | 34 | 23.25d | 0d | A2 Anslyst 2 | 16h | 1,120 |
| 36 | 6.1.2.3 | Develop code |  | 15d | 2004-08-20 | 2004-09-10 | 35 | 20.25d | 0d | P2 Programmer 2 | 120h | 7,800 |
| 37 | 6.1.2.4 | Developer testing (primary debugging) |  | 15d | 2004-11-15 | 2004-12-03 | 36FS-7.5% | 20d |  | P2 Programmer 2 | 120h | 7,800 |
| 38 | 6.1.3 | **Develop Data Capture System** |  | 92d | 2004-06-29 | 2004-11-08 |  | 39d |  |  | 344h | 22,480 |
| 39 | 6.1.3.1 | Review functional specifications |  | 1d | 2004-06-29 | 2004-06-29 |  | 40d | 0d | A1 Analyst 1 | 8h | 560 |
| 40 | 6.1.3.2 | Design screens and modules |  | 2d | 2004-06-30 | 2004-07-01 | 39 | 40d | 0d | A1 Analyst 1 | 16h | 1,120 |
| 41 | 6.1.3.3 | Develop code |  | 20d | 2004-07-19 | 2004-08-13 | 40 | 39d | 0d | P1Programmer 1 | 160h | 10,400 |
| 42 | 6.1.3.4 | Developer testing (primary debugging) |  | 20d | 2004-10-12 | 2004-11-08 | 41FS-7.5% | 39d |  | P1Programmer 1 | 160h | 10,400 |
| 43 | 6.1.4 | **Develop Data Publication System** |  | 123d | 2004-07-06 | 2004-12-24 |  | 5d |  |  | 264h | 17,280 |
| 44 | 6.1.4.1 | Review functional specifications |  | 1d | 2004-07-06 | 2004-07-06 |  | 5.25d | 0d | A2 Anslyst 2 | 8h | 560 |
| 45 | 6.1.4.2 | Design screens and modules |  | 2d | 2004-07-12 | 2004-07-13 | 44 | 5.25d | 0d | A2 Anslyst 2 | 16h | 1,120 |
| 46 | 6.1.4.3 | Develop code |  | 15d | 2004-09-13 | 2004-10-01 | 45 | 5.25d | 0d | P2 Programmer 2 | 120h | 7,800 |
| 47 | 6.1.4.4 | Developer testing (primary debugging) |  | 15d | 2004-12-06 | 2004-12-24 | 46FS-7.5% | 5d |  | P2 Programmer 2 | 120h | 7,800 |
| 48 | 6.1.5 | Development Complete | milestone | 0d | 2004-12-31 | 2004-12-31 | 28, 33, 38, 43 | 0d |  |  |  |  |
| 49 | 7 | **Testing** |  | 33d | 2005-01-03 | 2005-02-16 | 48 | 35d |  |  | 352h | 19,360 |
| 50 | 7.1 | Develop unit test plans using product specifications |  | 4d | 2005-01-03 | 2005-01-06 |  | 35d | 0d | T1 Tester 1; T2 Tester 2 | 64h | 3,520 |
| 51 | 7.2 | Develop integration test plans using product specifications |  | 2d | 2005-02-15 | 2005-02-16 |  | 63.33d |  | T1 Tester 1; T2 Tester 2 | 32h | 1,760 |
| 52 | 7.3 | **Unit Testing** |  | 7.5d | 2005-01-07 | 2005-01-18 |  | 35d |  |  | 120h | 6,600 |
| 53 | 7.3.1 | Review modular code |  | 2.5d | 2005-01-07 | 2005-01-11 | 50 | 35d | 0d | T1 Tester 1; T2 Tester 2 | 40h | 2,200 |
| 54 | 7.3.2 | Test component modules to product specifications |  | 1d | 2005-01-11 | 2005-01-12 | 53 | 35d | 0d | T1 Tester 1; T2 Tester 2 | 16h | 880 |
| 55 | 7.3.3 | Identify anomalies to product specifications |  | 1.5d | 2005-01-12 | 2005-01-13 | 54 | 35d | 0d | T1 Tester 1; T2 Tester 2 | 24h | 1,320 |
| 56 | 7.3.4 | Modify code |  | 1.5d | 2005-01-14 | 2005-01-17 | 55 | 35d | 0d | T2 Tester 2; T1 Tester 1 | 24h | 1,320 |
| 57 | 7.3.5 | Re-test modified code |  | 1d | 2005-01-17 | 2005-01-18 | 56 | 35d | 0d | T1 Tester 1; T2 Tester 2 | 16h | 880 |
| 58 | 7.3.6 | Unit testing complete | milestone | 0d | 2005-01-18 | 2005-01-18 | 57 | 35d | 0d |  |  |  |

| ID | WBS | Task | Type | Duration | Start | Finish | Predecessors | Total slack | Free slack | Resources | Work | Cost |
| --- | --- | --- | --- | --- | --- | --- | --- | --- | --- | --- | --- | --- |
| 59 | 7.4 | **Integration Testing** |  | 8.5d | 2005-01-18 | 2005-01-28 |  | 35d |  |  | 136h | 7,480 |
| 60 | 7.4.1 | Test module integration |  | 5d | 2005-01-18 | 2005-01-25 | 58 | 35d | 0d | T1 Tester 1; T2 Tester 2 | 80h | 4,400 |
| 61 | 7.4.2 | Identify anomalies to specifications |  | 1d | 2005-01-25 | 2005-01-26 | 60 | 35d | 0d | T1 Tester 1; T2 Tester 2 | 16h | 880 |
| 62 | 7.4.3 | Modify code |  | 1.5d | 2005-01-26 | 2005-01-27 | 61 | 35d | 0d | T1 Tester 1; T2 Tester 2 | 24h | 1,320 |
| 63 | 7.4.4 | Re-test modified code |  | 1d | 2005-01-28 | 2005-01-28 | 62 | 35d | 0d | T1 Tester 1; T2 Tester 2 | 16h | 880 |
| 64 | 7.4.5 | Integration testing complete | milestone | 0d | 2005-01-28 | 2005-01-28 | 63 | 35d | 0d |  |  |  |
| 65 | 8 | Send out Survey using survey production system |  | 1d | 2005-01-31 | 2005-01-31 | 64 | 35d | 0d | SD System Designer | 8h | 600 |
| 66 | 9 | Wait for survey results |  | 20d | 2005-02-01 | 2005-02-28 | 65 | 35d |  |  |  |  |
| 67 | 10 | **Training** |  | 71d | 2005-01-06 | 2005-04-14 | 48 | 2d |  |  | 256h | 15,360 |
| 68 | 10.1 | Develop training specifications for data operations personnel |  | 3d | 2005-01-06 | 2005-01-11 |  | 22d | 20d | TDS Training/Documentation | 24h | 1,440 |
| 69 | 10.2 | Develop training specifications for helpdesk support staff |  | 3d | 2005-02-02 | 2005-02-04 |  | 4d | 2d | TDS Training/Documentation | 24h | 1,440 |
| 70 | 10.3 | Identify training delivery methodology (computer based training, classroom, etc.) |  | 2d | 2005-02-07 | 2005-02-08 |  | 2d | 0d | TDS Training/Documentation | 16h | 960 |
| 71 | 10.4 | Develop training materials |  | 3w | 2005-02-09 | 2005-03-01 | 68, 69, 70 | 2d | 0d | TDS Training/Documentation | 120h | 7,200 |
| 72 | 10.5 | Conduct training usability study |  | 4d | 2005-03-28 | 2005-03-31 | 71 | 2d | 0d | TDS Training/Documentation | 32h | 1,920 |
| 73 | 10.6 | Finalize training materials |  | 3d | 2005-04-01 | 2005-04-05 | 72 | 2d | 0d | TDS Training/Documentation | 24h | 1,440 |
| 74 | 10.7 | Develop training delivery mechanism |  | 2d | 2005-04-13 | 2005-04-14 | 73 | 2d | 0d | TDS Training/Documentation | 16h | 960 |
| 75 | 10.8 | Training materials complete | milestone | 0d | 2005-04-14 | 2005-04-14 | 74 | 2d |  |  |  |  |
| 76 | 11 | **Documentation** |  | 76d | 2005-01-03 | 2005-04-18 | 48 | 0d |  |  | 336h | 20,160 |
| 77 | 11.1 | Develop Help specification |  | 1d | 2005-01-05 | 2005-01-05 |  | 5.5d | 0.5d | TDS Training/Documentation | 8h | 480 |
| 78 | 11.2 | Develop Help system |  | 3w | 2005-01-12 | 2005-02-01 | 77 | 5d | 0d | TDS Training/Documentation | 120h | 7,200 |
| 79 | 11.3 | Review Help documentation |  | 3d | 2005-03-23 | 2005-03-25 | 78 | 5d | 1d | TDS Training/Documentation | 24h | 1,440 |
| 80 | 11.4 | Incorporate Help documentation feedback |  | 2d | 2005-04-11 | 2005-04-12 | 79 | 4d |  | TDS Training/Documentation | 16h | 960 |
| 81 | 11.5 | Develop user manuals specifications |  | 2d | 2005-01-03 | 2005-01-04 |  | 0d |  | TDS Training/Documentation | 16h | 960 |
| 82 | 11.6 | Develop user manuals |  | 3w | 2005-03-02 | 2005-03-22 | 81 | 0d |  | TDS Training/Documentation | 120h | 7,200 |
| 83 | 11.7 | Review all user documentation |  | 2d | 2005-04-06 | 2005-04-07 | 82 | 0d |  | TDS Training/Documentation | 16h | 960 |
| 84 | 11.8 | Incorporate user documentation feedback |  | 2d | 2005-04-15 | 2005-04-18 | 83 | 0d |  | TDS Training/Documentation | 16h | 960 |
| 85 | 11.9 | Documentation complete | milestone | 0d | 2005-04-18 | 2005-04-18 | 80, 84 | 0d |  |  |  |  |
| 86 | 12 | Process survey results with survey processing system |  | 3.33d | 2005-04-19 | 2005-04-22 | 66, 75, 85 | 0d |  | A1 Analyst 1; P1Programmer 1; T1 Tester 1 | 80h | 5,066.67 |

| ID | WBS | Task | Type | Duration | Start | Finish | Predecessors | Total slack | Resources | Work | Cost |
| --- | --- | --- | --- | --- | --- | --- | --- | --- | --- | --- | --- |
| 87 | 13 | **Pilot** |  | 9d | 2005-04-22 | 2005-05-05 | 66, 85, 75, 86 | 0d |  | 72h | 5,240 |
| 88 | 13.1 | Identify test group |  | 1d | 2005-04-22 | 2005-04-25 |  | 0d | Project manager | 8h | 600 |
| 89 | 13.2 | Develop software delivery mechanism |  | 1d | 2005-04-25 | 2005-04-26 | 88 | 0d | P2 Programmer 2 | 8h | 520 |
| 90 | 13.3 | Install/deploy software |  | 1d | 2005-04-26 | 2005-04-27 | 75, 85, 89 | 0d | P2 Programmer 2 | 8h | 520 |
| 91 | 13.4 | Obtain user feedback |  | 1w | 2005-04-27 | 2005-05-04 | 90 | 0d | Project manager | 40h | 3,000 |
| 92 | 13.5 | Evaluate testing information |  | 1d | 2005-05-04 | 2005-05-05 | 91 | 0d | Project manager | 8h | 600 |
| 93 | 13.6 | Pilot complete | milestone | 0d | 2005-05-05 | 2005-05-05 | 92 | 0d |  |  |  |
| 94 | 14 | **Deployment** |  | 5d | 2005-05-05 | 2005-05-12 |  | 0d |  | 40h | 2,800 |
| 95 | 14.1 | Determine final deployment strategy |  | 1d | 2005-05-05 | 2005-05-06 | 93 | 0d | Project manager | 8h | 600 |
| 96 | 14.2 | Develop deployment methodology |  | 1d | 2005-05-06 | 2005-05-09 | 95 | 0d | SD System Designer | 8h | 600 |
| 97 | 14.3 | Secure deployment resources |  | 1d | 2005-05-09 | 2005-05-10 | 96 | 0d | Project manager | 8h | 600 |
| 98 | 14.4 | Train support staff |  | 1d | 2005-05-10 | 2005-05-11 | 97 | 0d | TDS Training/Documentation | 8h | 480 |
| 99 | 14.5 | Deploy software |  | 1d | 2005-05-11 | 2005-05-12 | 98 | 0d | P2 Programmer 2 | 8h | 520 |
| 100 | 14.6 | Deployment complete | milestone | 0d | 2005-05-12 | 2005-05-12 | 99 | 0d |  |  |  |
| 101 | 15 | **Post Implementation Review** |  | 3d | 2005-05-12 | 2005-05-17 |  | 0d |  | 24h | 1,787.5 |
| 102 | 15.1 | Document lessons learned |  | 1d | 2005-05-12 | 2005-05-13 | 100 | 0d | Project manager [12.5%]; CS Client Sponsor [12.5%]; A1 Analyst 1 [12.5%]; P1Programmer 1 [12.5%]; T1 Tester 1 [12.5%]; TDS Training/Documentation [12.5%]; DBA Database Administrator [12.5%]; SD System Designer [12.5%] | 8h | 587.5 |
| 103 | 15.2 | Distribute to team members |  | 1d | 2005-05-13 | 2005-05-16 | 102 | 0d | Project manager | 8h | 600 |
| 104 | 15.3 | Create software maintenance team |  | 1d | 2005-05-16 | 2005-05-17 | 103 | 0d | Project manager | 8h | 600 |
| 105 | 15.4 | Post implementation review complete | milestone | 0d | 2005-05-17 | 2005-05-17 | 104 | 0d |  |  |  |
| 106 | 16 | Project complete | milestone | 0d | 2005-05-17 | 2005-05-17 | 105 | 0d |  |  |  |
